# Cronograma Aplicativo web - Solutechnology 02.12.2020

Schedule from MS Project, 2020-08-03 to 2021-05-17, status date 2020-12-02, costs in $, A marks actual dates.
Microsoft

## Calendars

- Estándar: Mon-Fri 08:00-13:00, 14:00-17:00; Sat-Sun off. Exceptions (off unless hours are given): 2020-08-07 (Festivo), 2020-08-17 (Festivo), 2020-10-12 (Festivo), 2020-11-02 (Festivo), 2020-11-16 (Festivo), 2020-12-08 (Festivo), 2020-12-25 (Festivo), 2021-01-01 (Festivo), 2021-01-11 (Festivo), 2021-03-22 (Festivo), 2021-04-01 to 2021-04-02 (Festivo), 2021-05-01 (Festivo).

## Resources

| Resource | Rate |
| --- | --- |
| Gerente General | 159911 |
| Gerente Financiero | 59911 |
| Coordinador de proyectos | 44286 |
| Ingeniero de proyectos 1 | 25536 |
| Ingeniero de proyectos 1 | 25536 |
| Líder de RH | 34911 |
| Coordinador de TI | 44286 |
| Coordinador de calidad | 34911 |
| Gerente de proyecto (E) | 84375 |
| Gerente General (E) | 140625 |
| Jefe de aplicaciones (E) | 46875 |
| Analista de aplicaciones (E) | 37500 |
| Proveedor de servicios en la nube | 56250 |

## Schedule

| ID | WBS | Task | Type | Duration | Start | Finish | Predecessors | Complete | Remaining | Baseline start | Baseline finish | Baseline duration | Total slack | Resources | Work | Actual work | Cost | Baseline cost | Actual cost | Planificado | % Planned |
| --- | --- | --- | --- | --- | --- | --- | --- | --- | --- | --- | --- | --- | --- | --- | --- | --- | --- | --- | --- | --- | --- |
| 1 | 1 | **Proyecto** |  | 194d | 2020-08-03 A | 2021-05-17 |  | 33% | 129.79d | 2020-08-03 | 2021-05-17 | 194d | 0d |  | 2055.2h | 815.2h | 208,220,711.6 | 208,483,211.6 | 86,567,031.8 | 6% | 36% |
| 2 | 1.1 | **Gestión del proyecto** |  | 194d | 2020-08-03 A | 2021-05-17 |  | 93% | 14.48d | 2020-08-03 | 2021-05-17 | 194d | 0d |  | 604h | 572h | 40,629,776.8 | 40,629,776.8 | 37,929,776.8 | 27% | 93% |
| 3 | 1.1.1 | **Inicio** |  | 13d | 2020-08-03 A | 2020-08-21 A |  | 100% |  | 2020-08-03 | 2020-08-21 | 13d |  |  | 173.6h | 173.6h | 10,795,456.8 | 10,795,456.8 | 10,795,456.8 | 100% | 100% |
| 4 | 1.1.1.1 | Definir el alcance, costo y duración del proyecto |  | 5d | 2020-08-03 A | 2020-08-10 A |  | 100% |  | 2020-08-03 | 2020-08-10 | 5d |  | Gerente de proyecto (E) [40%]; Gerente Financiero [20%]; Coordinador de proyectos [80%] | 56h | 56h | 3,246,440 | 3,246,440 | 3,246,440 | 100% | 100% |
| 5 | 1.1.1.2 | Revisar condiciones técnicas del proyecto |  | 2d | 2020-08-11 A | 2020-08-12 A | 4 | 100% |  | 2020-08-11 | 2020-08-12 | 2d |  | Gerente de proyecto (E) [80%]; Coordinador de proyectos [80%] | 25.6h | 25.6h | 1,646,860.8 | 1,646,860.8 | 1,646,860.8 | 100% | 100% |
| 6 | 1.1.1.3 | Diligenciar acta de constitución |  | 2d | 2020-08-13 A | 2020-08-14 A | 4, 5 | 100% |  | 2020-08-13 | 2020-08-14 | 2d |  | Gerente de proyecto (E) [80%]; Coordinador de proyectos [80%] | 25.6h | 25.6h | 1,646,860.8 | 1,646,860.8 | 1,646,860.8 | 100% | 100% |
| 7 | 1.1.1.4 | Realizar reunión de inicio del proyecto |  | 1d | 2020-08-18 A | 2020-08-18 A | 6 | 100% |  | 2020-08-18 | 2020-08-18 | 1d |  | Coordinador de proyectos [80%]; Coordinador de TI [50%]; Gerente de proyecto (E) [80%]; Gerente General (E) [25%]; Ingeniero de proyectos 1 [50%]; Jefe de aplicaciones (E) [70%]; Gerente General [25%] | 34.4h | 34.4h | 2,068,434.4 | 2,068,434.4 | 2,068,434.4 | 100% | 100% |
| 8 | 1.1.1.5 | Identificar interesados |  | 2d | 2020-08-19 A | 2020-08-20 A | 7 | 100% |  | 2020-08-19 | 2020-08-20 | 2d |  | Coordinador de proyectos [80%]; Gerente de proyecto (E) [80%] | 25.6h | 25.6h | 1,646,860.8 | 1,646,860.8 | 1,646,860.8 | 100% | 100% |
| 9 | 1.1.1.6 | Crear y diligenciar matriz de interesados |  | 1d | 2020-08-21 A | 2020-08-21 A | 8 | 100% |  | 2020-08-21 | 2020-08-21 | 1d |  | Gerente de proyecto (E) [80%] | 6.4h | 6.4h | 540,000 | 540,000 | 540,000 | 100% | 100% |
| 10 | 1.1.1.7 | Proyecto iniciado | milestone | 0d | 2020-08-21 A | 2020-08-21 A | 9 | 100% |  | 2020-08-21 | 2020-08-21 | 0d |  |  |  |  |  |  |  | 100% | 100% |
| 11 | 1.1.2 | **Planeación** |  | 33d | 2020-08-24 A | 2020-10-07 A |  | 100% |  | 2020-08-24 | 2020-10-07 | 33d |  |  | 300.8h | 300.8h | 21,272,588.8 | 21,272,588.8 | 21,272,588.8 | 15% | 100% |
| 12 | 1.1.2.1 | Realizar el plan de gestión de alcance |  | 2d | 2020-08-24 A | 2020-08-25 A | 9 | 100% |  | 2020-08-24 | 2020-08-25 | 2d |  | Gerente de proyecto (E) [80%]; Coordinador de proyectos [80%] | 25.6h | 25.6h | 1,646,860.8 | 1,646,860.8 | 1,646,860.8 | 100% | 100% |
| 13 | 1.1.2.2 | Realizar plan de gestión de cronogramas |  | 3d | 2020-08-26 A | 2020-08-28 A | 12 | 100% |  | 2020-08-26 | 2020-08-28 | 3d |  | Gerente de proyecto (E) [80%] | 19.2h | 19.2h | 1,620,000 | 1,620,000 | 1,620,000 | 100% | 100% |
| 14 | 1.1.2.3 | Realizar plan de gestión de costos |  | 3d | 2020-08-31 A | 2020-09-02 A | 13 | 100% |  | 2020-08-31 | 2020-09-02 | 3d |  | Gerente de proyecto (E) [80%] | 19.2h | 19.2h | 1,620,000 | 1,620,000 | 1,620,000 | 0% | 100% |
| 15 | 1.1.2.4 | Realizar el plan de gestión de calidad |  | 3d | 2020-09-03 A | 2020-09-07 A | 14 | 100% |  | 2020-09-03 | 2020-09-07 | 3d |  | Gerente de proyecto (E) [80%] | 19.2h | 19.2h | 1,620,000 | 1,620,000 | 1,620,000 | 0% | 100% |
| 16 | 1.1.2.5 | Realizar plan de gestión de recursos |  | 3d | 2020-09-08 A | 2020-09-10 A | 15 | 100% |  | 2020-09-08 | 2020-09-10 | 3d |  | Gerente de proyecto (E) [80%] | 19.2h | 19.2h | 1,620,000 | 1,620,000 | 1,620,000 | 0% | 100% |
| 17 | 1.1.2.6 | Realizar plan de gestión de comunicaciones |  | 2d | 2020-09-11 A | 2020-09-14 A | 16 | 100% |  | 2020-09-11 | 2020-09-14 | 2d |  | Gerente de proyecto (E) [80%]; Líder de RH [50%] | 20.8h | 20.8h | 1,359,288 | 1,359,288 | 1,359,288 | 0% | 100% |
| 18 | 1.1.2.7 | Realizar plan de gestión de riesgos |  | 3d | 2020-09-15 A | 2020-09-17 A | 17 | 100% |  | 2020-09-15 | 2020-09-17 | 3d |  | Gerente de proyecto (E) [80%] | 19.2h | 19.2h | 1,620,000 | 1,620,000 | 1,620,000 | 0% | 100% |
| 19 | 1.1.2.8 | Realizar plan de gestión de adquisiciones |  | 2d | 2020-09-18 A | 2020-09-21 A | 18 | 100% |  | 2020-09-18 | 2020-09-21 | 2d |  | Gerente de proyecto (E) [80%]; Coordinador de proyectos [80%]; Gerente Financiero [40%] | 32h | 32h | 2,030,291.2 | 2,030,291.2 | 2,030,291.2 | 0% | 100% |
| 20 | 1.1.2.9 | Realizar plan de involucramiento de interesados |  | 2d | 2020-09-22 A | 2020-09-23 A | 19 | 100% |  | 2020-09-22 | 2020-09-23 | 2d |  | Coordinador de proyectos [80%]; Gerente de proyecto (E) [80%] | 25.6h | 25.6h | 1,646,860.8 | 1,646,860.8 | 1,646,860.8 | 0% | 100% |
| 21 | 1.1.2.10 | Realizar plan de gestión de infraestructura de TI |  | 2d | 2020-09-24 A | 2020-09-25 A | 20 | 100% |  | 2020-09-24 | 2020-09-25 | 2d |  | Jefe de aplicaciones (E) [70%] | 11.2h | 11.2h | 525,000 | 525,000 | 525,000 | 0% | 100% |
| 22 | 1.1.2.11 | Realizar plan de migración de datos |  | 2d | 2020-09-28 A | 2020-09-29 A | 21 | 100% |  | 2020-09-28 | 2020-09-29 | 2d |  | Gerente de proyecto (E) [80%]; Analista de aplicaciones (E) [80%] | 25.6h | 25.6h | 1,560,000 | 1,560,000 | 1,560,000 | 0% | 100% |
| 23 | 1.1.2.12 | Realizar plan de pruebas |  | 2d | 2020-09-30 A | 2020-10-01 A | 22 | 100% |  | 2020-09-30 | 2020-10-01 | 2d |  | Gerente de proyecto (E) [80%] | 12.8h | 12.8h | 1,080,000 | 1,080,000 | 1,080,000 | 0% | 100% |
| 24 | 1.1.2.13 | Realizar plan de gestión del cambio |  | 2d | 2020-10-02 A | 2020-10-05 A | 23 | 100% |  | 2020-10-02 | 2020-10-05 | 2d |  | Gerente de proyecto (E) [80%]; Líder de RH [50%] | 20.8h | 20.8h | 1,359,288 | 1,359,288 | 1,359,288 | 0% | 100% |
| 25 | 1.1.2.14 | Realizar plan de cutover |  | 2d | 2020-10-06 A | 2020-10-07 A | 24 | 100% |  | 2020-10-06 | 2020-10-07 | 2d |  | Gerente de proyecto (E) [80%]; Proveedor de servicios en la nube [40%]; Jefe de aplicaciones (E) [70%] | 30.4h | 30.4h | 1,965,000 | 1,965,000 | 1,965,000 | 0% | 100% |
| 26 | 1.1.2.15 | Planeación completada | milestone | 0d | 2020-10-07 A | 2020-10-07 A | 25 | 100% |  | 2020-10-07 | 2020-10-07 | 0d |  |  |  |  |  |  |  | 0% | 100% |

| ID | WBS | Task | Type | Duration | Start | Finish | Predecessors | Complete | Remaining | Baseline start | Baseline finish | Baseline duration | Total slack | Resources | Work | Actual work | Cost | Baseline cost | Actual cost | Planificado | % Planned |
| --- | --- | --- | --- | --- | --- | --- | --- | --- | --- | --- | --- | --- | --- | --- | --- | --- | --- | --- | --- | --- | --- |
| 27 | 1.1.3 | **Monitoreo y control** |  | 9d | 2020-10-08 A | 2020-10-21 A |  | 100% |  | 2020-10-08 | 2020-10-21 | 9d |  |  | 72h | 72h | 4,728,009.6 | 4,728,009.6 | 4,728,009.6 | 0% | 100% |
| 28 | 1.1.3.1 | Identificar informes y formatos de seguimiento |  | 1d | 2020-10-09 A | 2020-10-09 A | 25FS+1d | 100% |  | 2020-10-09 | 2020-10-09 | 1d |  | Gerente de proyecto (E) [80%] | 6.4h | 6.4h | 540,000 | 540,000 | 540,000 | 0% | 100% |
| 29 | 1.1.3.2 | Seleccionar y aprobar formatos de seguimiento |  | 2d | 2020-10-14 A | 2020-10-15 A | 28 | 100% |  | 2020-10-14 | 2020-10-15 | 2d |  | Coordinador de proyectos [80%] | 12.8h | 12.8h | 566,860.8 | 566,860.8 | 566,860.8 | 0% | 100% |
| 30 | 1.1.3.3 | Identificar informes de desempeño |  | 1d | 2020-10-08 A | 2020-10-08 A | 25 | 100% |  | 2020-10-08 | 2020-10-08 | 1d |  | Gerente de proyecto (E) [80%] | 6.4h | 6.4h | 540,000 | 540,000 | 540,000 | 0% | 100% |
| 31 | 1.1.3.4 | Seleccionar y aprobar informes de desempeño |  | 2d | 2020-10-09 A | 2020-10-13 A | 30 | 100% |  | 2020-10-09 | 2020-10-13 | 2d |  | Coordinador de proyectos [80%] | 12.8h | 12.8h | 566,860.8 | 566,860.8 | 566,860.8 | 0% | 100% |
| 32 | 1.1.3.5 | Planificar y presentar gobernanza del proyecto |  | 4d | 2020-10-14 A | 2020-10-19 A | 31 | 100% |  | 2020-10-14 | 2020-10-19 | 4d |  | Gerente de proyecto (E) [80%] | 25.6h | 25.6h | 2,160,000 | 2,160,000 | 2,160,000 | 0% | 100% |
| 33 | 1.1.3.6 | Aprobar gobernanza del proyecto |  | 2d | 2020-10-20 A | 2020-10-21 A | 32 | 100% |  | 2020-10-20 | 2020-10-21 | 2d |  | Coordinador de TI [50%] | 8h | 8h | 354,288 | 354,288 | 354,288 | 0% | 100% |
| 34 | 1.1.4 | **Actividades de cierre** |  | 137d | 2020-10-26 A | 2021-05-17 |  | 44% | 76.11d | 2020-10-26 | 2021-05-17 | 137d | 0d |  | 57.6h | 25.6h | 3,833,721.6 | 3,833,721.6 | 1,133,721.6 | 0% | 44% |
| 35 | 1.1.4.1 | Definir criterios de aceptación para los entregables |  | 4d | 2020-10-26 A | 2020-10-29 A | 33 | 100% |  | 2020-10-26 | 2020-10-29 | 4d |  | Coordinador de proyectos [80%] | 25.6h | 25.6h | 1,133,721.6 | 1,133,721.6 | 1,133,721.6 | 0% | 100% |
| 36 | 1.1.4.2 | Cerrar proyecto con acta |  | 5d | 2021-05-05 | 2021-05-17 | 161SS |  |  | 2021-05-05 | 2021-05-17 | 5d | 0d | Gerente de proyecto (E) [80%] | 32h |  | 2,700,000 | 2,700,000 |  | 0% | 0% |
| 37 | 1.2 | **Requerimientos y analisis** |  | 29d | 2020-10-08 A | 2020-11-20 A |  | 100% |  | 2020-10-08 | 2020-11-20 | 29d |  |  | 243.2h | 243.2h | 48,637,255 | 48,637,255 | 48,637,255 | 0% | 100% |
| 38 | 1.2.1 | **Levantamiento de requerimientos** |  | 17d | 2020-10-08 A | 2020-11-03 A |  | 100% |  | 2020-10-08 | 2020-11-03 | 17d |  |  | 108h | 108h | 4,036,723.2 | 4,036,723.2 | 4,036,723.2 | 0% | 100% |
| 39 | 1.2.1.1 | Planificar ejecución de entrevistas |  | 2d | 2020-10-08 A | 2020-10-09 A | 25 | 100% |  | 2020-10-08 | 2020-10-09 | 2d |  | Analista de aplicaciones (E) [80%] | 12.8h | 12.8h | 480,000 | 480,000 | 480,000 | 0% | 100% |
| 40 | 1.2.1.2 | Ejecutar entrevistas |  | 3d | 2020-10-13 A | 2020-10-15 A | 39 | 100% |  | 2020-10-13 | 2020-10-15 | 3d |  | Analista de aplicaciones (E) [80%] | 19.2h | 19.2h | 720,000 | 720,000 | 720,000 | 0% | 100% |
| 41 | 1.2.1.3 | Entregar informe de requerimientos |  | 3d | 2020-10-16 A | 2020-10-20 A | 40 | 100% |  | 2020-10-16 | 2020-10-20 | 3d |  | Analista de aplicaciones (E) [80%] | 19.2h | 19.2h | 720,000 | 720,000 | 720,000 | 0% | 100% |
| 42 | 1.2.1.4 | Validar requerimientos |  | 3d | 2020-10-21 A | 2020-10-23 A | 41 | 100% |  | 2020-10-21 | 2020-10-23 | 3d |  | Coordinador de proyectos [80%]; Ingeniero de proyectos 1 [50%] | 31.2h | 31.2h | 1,156,723.2 | 1,156,723.2 | 1,156,723.2 | 0% | 100% |
| 43 | 1.2.1.5 | Entregar requerimientos |  | 2d | 2020-10-26 A | 2020-10-27 A | 42 | 100% |  | 2020-10-26 | 2020-10-27 | 2d |  | Analista de aplicaciones (E) [80%] | 12.8h | 12.8h | 480,000 | 480,000 | 480,000 | 0% | 100% |
| 44 | 1.2.1.6 | Seleccionar formato de acta de levantamiento de información |  | 1d | 2020-10-21 A | 2020-10-21 A | 39SS | 100% |  | 2020-10-21 | 2020-10-21 | 1d |  | Analista de aplicaciones (E) [80%] | 6.4h | 6.4h | 240,000 | 240,000 | 240,000 | 0% | 100% |
| 45 | 1.2.1.7 | Diligenciar acta de levantamiento de información |  | 1d | 2020-11-03 A | 2020-11-03 A | 43, 44 | 100% |  | 2020-11-03 | 2020-11-03 | 1d |  | Analista de aplicaciones (E) [80%] | 6.4h | 6.4h | 240,000 | 240,000 | 240,000 | 0% | 100% |
| 46 | 1.2.1.8 | Requerimientos levantados | milestone | 0d | 2020-11-03 A | 2020-11-03 A | 45 | 100% |  | 2020-11-03 | 2020-11-03 | 0d |  |  |  |  |  |  |  | 0% | 100% |
| 47 | 1.2.2 | **Analisis de requerimientos** |  | 16d | 2020-10-28 A | 2020-11-20 A |  | 100% |  | 2020-10-28 | 2020-11-20 | 16d |  |  | 135.2h | 135.2h | 5,911,156.8 | 5,911,156.8 | 5,911,156.8 | 0% | 100% |
| 48 | 1.2.2.1 | **Documento Funcional** |  | 9d | 2020-10-28 A | 2020-11-10 A |  | 100% |  | 2020-10-28 | 2020-11-10 | 9d |  |  | 74.4h | 74.4h | 3,464,652 | 3,464,652 | 3,464,652 | 0% | 100% |
| 49 | 1.2.2.1.1 | Realizar construcción de documento funcional |  | 3d | 2020-10-28 A | 2020-10-30 A | 43 | 100% |  | 2020-10-28 | 2020-10-30 | 3d |  | Analista de aplicaciones (E) [80%] | 19.2h | 19.2h | 720,000 | 720,000 | 720,000 | 0% | 100% |
| 50 | 1.2.2.1.2 | Realizar validación de documento funcional |  | 1d | 2020-11-03 A | 2020-11-03 A | 49 | 100% |  | 2020-11-03 | 2020-11-03 | 1d |  | Jefe de aplicaciones (E) [70%]; Gerente de proyecto (E) [80%] | 12h | 12h | 802,500 | 802,500 | 802,500 | 0% | 100% |
| 51 | 1.2.2.1.3 | Realizar presentación / validación de documento funcional |  | 2d | 2020-11-04 A | 2020-11-05 A | 50 | 100% |  | 2020-11-04 | 2020-11-05 | 2d |  | Jefe de aplicaciones (E) [70%]; Coordinador de proyectos [80%] | 24h | 24h | 1,091,860.8 | 1,091,860.8 | 1,091,860.8 | 0% | 100% |
| 52 | 1.2.2.1.4 | Ejecutar la aprobación documento funcional |  | 3d | 2020-11-06 A | 2020-11-10 A | 51 | 100% |  | 2020-11-06 | 2020-11-10 | 3d |  | Coordinador de proyectos [80%] | 19.2h | 19.2h | 850,291.2 | 850,291.2 | 850,291.2 | 0% | 100% |

| ID | WBS | Task | Type | Duration | Start | Finish | Predecessors | Complete | Baseline start | Baseline finish | Baseline duration | Total slack | Free slack | Resources | Work | Actual work | Cost | Baseline cost | Actual cost | Planificado | % Planned |
| --- | --- | --- | --- | --- | --- | --- | --- | --- | --- | --- | --- | --- | --- | --- | --- | --- | --- | --- | --- | --- | --- |
| 53 | 1.2.2.2 | **Documento Técnico** |  | 7d | 2020-11-11 A | 2020-11-20 A |  | 100% | 2020-11-11 | 2020-11-20 | 7d |  |  |  | 60.8h | 60.8h | 2,446,504.8 | 2,446,504.8 | 2,446,504.8 | 0% | 100% |
| 54 | 1.2.2.2.1 | Realizar construcción de documento técnico |  | 3d | 2020-11-11 A | 2020-11-13 A | 52 | 100% | 2020-11-11 | 2020-11-13 | 3d |  |  | Analista de aplicaciones (E) [80%] | 19.2h | 19.2h | 720,000 | 720,000 | 720,000 | 0% | 100% |
| 55 | 1.2.2.2.2 | Realizar validación de documento técnico |  | 1d | 2020-11-17 A | 2020-11-17 A | 54 | 100% | 2020-11-17 | 2020-11-17 | 1d |  |  | Analista de aplicaciones (E) [80%]; Jefe de aplicaciones (E) [70%] | 12h | 12h | 502,500 | 502,500 | 502,500 | 0% | 100% |
| 56 | 1.2.2.2.3 | Realizar presentación / validación de documento técnico |  | 2d | 2020-11-18 A | 2020-11-19 A | 55 | 100% | 2020-11-18 | 2020-11-19 | 2d |  |  | Analista de aplicaciones (E) [80%]; Coordinador de proyectos [80%] | 25.6h | 25.6h | 1,046,860.8 | 1,046,860.8 | 1,046,860.8 | 0% | 100% |
| 57 | 1.2.2.2.4 | Ejecutar la aprobación documento técnico |  | 1d | 2020-11-20 A | 2020-11-20 A | 56 | 100% | 2020-11-20 | 2020-11-20 | 1d |  |  | Coordinador de TI [50%] | 4h | 4h | 177,144 | 177,144 | 177,144 | 0% | 100% |
| 58 | 1.2.3 | Analisis realizado | milestone | 0d | 2020-11-20 A | 2020-11-20 A | 57 | 100% | 2020-11-20 | 2020-11-20 | 0d |  |  |  |  |  |  |  |  | 0% | 100% |
| 59 | 1.2.4 | Licenciar aplicativo parte 1 | milestone | 0d | 2020-11-20 A | 2020-11-20 A | 57 | 100% | 2020-11-20 | 2020-11-20 | 0d |  |  |  |  |  | 38,689,375 | 38,689,375 | 38,689,375 | 0% | 100% |
| 60 | 1.3 | **Construcción** |  | 45d | 2020-11-23 | 2021-01-28 |  |  | 2020-11-23 | 2021-01-28 | 45d | 0d |  |  | 288h |  | 10,800,000 | 10,800,000 |  | 0% | 16% |
| 61 | 1.3.1 | **Desarrollo** |  | 35d | 2020-11-23 | 2021-01-14 |  |  | 2020-11-23 | 2021-01-14 | 35d | 0d |  |  | 224h |  | 8,400,000 | 8,400,000 |  | 0% | 23% |
| 62 | 1.3.1.1 | Revisar e interpretar el documento técnico |  | 5d | 2020-11-23 | 2020-11-27 | 57 |  | 2020-11-23 | 2020-11-27 | 5d | 0d |  | Analista de aplicaciones (E) [80%] | 32h |  | 1,200,000 | 1,200,000 |  | 0% | 100% |
| 63 | 1.3.1.2 | Ejecutar el desarrollo/configuración |  | 30d | 2020-11-30 | 2021-01-14 | 62 |  | 2020-11-30 | 2021-01-14 | 30d | 0d |  | Analista de aplicaciones (E) [80%] | 192h |  | 7,200,000 | 7,200,000 |  | 0% | 10% |
| 64 | 1.3.2 | **Pruebas unitarias** |  | 7d | 2021-01-15 | 2021-01-25 |  |  | 2021-01-15 | 2021-01-25 | 7d | 0d |  |  | 44.8h |  | 1,680,000 | 1,680,000 |  | 0% | 0% |
| 65 | 1.3.2.1 | Planificar las pruebas unitarias |  | 2d | 2021-01-15 | 2021-01-18 | 63 |  | 2021-01-15 | 2021-01-18 | 2d | 0d |  | Analista de aplicaciones (E) [80%] | 12.8h |  | 480,000 | 480,000 |  | 0% | 0% |
| 66 | 1.3.2.2 | Ejecutar las pruebas unitarias |  | 5d | 2021-01-19 | 2021-01-25 | 65 |  | 2021-01-19 | 2021-01-25 | 5d | 0d |  | Analista de aplicaciones (E) [80%] | 32h |  | 1,200,000 | 1,200,000 |  | 0% | 0% |
| 67 | 1.3.2.3 | Realizar corrección de defectos y actualización de código |  | 5d | 2021-01-19 | 2021-01-25 | 66SS |  | 2021-01-19 | 2021-01-25 | 5d | 0d |  |  |  |  |  |  |  | 0% | 0% |
| 68 | 1.3.3 | Actualizar documento técnico |  | 2d | 2021-01-26 | 2021-01-27 | 67 |  | 2021-01-26 | 2021-01-27 | 2d | 0d |  | Analista de aplicaciones (E) [80%] | 12.8h |  | 480,000 | 480,000 |  | 0% | 0% |
| 69 | 1.3.4 | Completar y documentar código de desarrollo versionado |  | 1d | 2021-01-28 | 2021-01-28 | 68 |  | 2021-01-28 | 2021-01-28 | 1d | 1d | 0d | Analista de aplicaciones (E) [80%] | 6.4h |  | 240,000 | 240,000 |  | 0% | 0% |
| 70 | 1.3.5 | Construcción terminada | milestone | 0d | 2021-01-28 | 2021-01-28 | 69 |  | 2021-01-28 | 2021-01-28 | 0d | 74d |  |  |  |  |  |  |  | 0% | 0% |
| 71 | 1.4 | **Pruebas** |  | 34d | 2021-01-25 | 2021-03-11 |  |  | 2021-01-25 | 2021-03-11 | 34d | 0d |  |  | 329.6h |  | 14,882,726.4 | 14,882,726.4 |  | 0% | 0% |
| 72 | 1.4.1 | **Pruebas de integración** |  | 20d | 2021-01-25 | 2021-02-19 |  |  | 2021-01-25 | 2021-02-19 | 20d | 0d |  |  | 144h |  | 7,110,000 | 7,110,000 |  | 0% | 0% |
| 73 | 1.4.1.1 | Requerir y alistar ambiente de pruebas |  | 2d | 2021-01-26 | 2021-01-27 | 68SS |  | 2021-01-26 | 2021-01-27 | 2d | 0d |  | Jefe de aplicaciones (E) [70%] | 11.2h |  | 525,000 | 525,000 |  | 0% | 0% |
| 74 | 1.4.1.2 | Instalar aplicación desarrollada |  | 1d | 2021-01-29 | 2021-01-29 | 69, 73 |  | 2021-01-29 | 2021-01-29 | 1d | 1d | 0d | Analista de aplicaciones (E) [80%] | 6.4h |  | 240,000 | 240,000 |  | 0% | 0% |
| 75 | 1.4.1.3 | Cargar datos y crear usuarios |  | 1d | 2021-02-03 | 2021-02-03 | 74SS |  | 2021-02-03 | 2021-02-03 | 1d | 1d | 0d | Analista de aplicaciones (E) [80%] | 6.4h |  | 240,000 | 240,000 |  | 0% | 0% |
| 76 | 1.4.1.4 | Realizar smoke tests al ambiente (validar ambiente) |  | 1d | 2021-02-04 | 2021-02-04 | 75 |  | 2021-02-04 | 2021-02-04 | 1d | 1d |  | Analista de aplicaciones (E) [80%] | 6.4h |  | 240,000 | 240,000 |  | 0% | 0% |
| 77 | 1.4.1.5 | Realizar plan de prueba |  | 2d | 2021-01-25 | 2021-01-26 | 73SS-1d |  | 2021-01-25 | 2021-01-26 | 2d | 0d |  | Gerente de proyecto (E) [80%] | 12.8h |  | 1,080,000 | 1,080,000 |  | 0% | 0% |
| 78 | 1.4.1.6 | Presentar/aprobar el plan de pruebas |  | 1d | 2021-01-27 | 2021-01-27 | 77 |  | 2021-01-27 | 2021-01-27 | 1d | 0d |  | Gerente de proyecto (E) [80%] | 6.4h |  | 540,000 | 540,000 |  | 0% | 0% |
| 79 | 1.4.1.7 | Identificar escenarios de prueba |  | 4d | 2021-01-28 | 2021-02-02 | 78 |  | 2021-01-28 | 2021-02-02 | 4d | 0d |  | Gerente de proyecto (E) [80%]; Analista de aplicaciones (E) [80%] | 25.6h |  | 1,560,000 | 1,560,000 |  | 0% | 0% |
| 80 | 1.4.1.8 | Realizar descripción de escenarios y resultados esperados |  | 1d | 2021-02-05 | 2021-02-05 | 79 |  | 2021-02-05 | 2021-02-05 | 1d | 0d |  | Analista de aplicaciones (E) [80%] | 6.4h |  | 240,000 | 240,000 |  | 0% | 0% |
| 81 | 1.4.1.9 | Ejecutar pruebas y solucionar defectos |  | 7d | 2021-02-08 | 2021-02-16 | 80, 76 |  | 2021-02-08 | 2021-02-16 | 7d | 0d |  | Analista de aplicaciones (E) [80%] | 44.8h |  | 1,680,000 | 1,680,000 |  | 0% | 0% |
| 82 | 1.4.1.10 | Realizar y entregar reporte de resultados |  | 2d | 2021-02-17 | 2021-02-18 | 81 |  | 2021-02-17 | 2021-02-18 | 2d | 0d |  | Jefe de aplicaciones (E) [70%] | 11.2h |  | 525,000 | 525,000 |  | 0% | 0% |
| 83 | 1.4.1.11 | Actualizar versión de código testeado |  | 1d | 2021-02-19 | 2021-02-19 | 82 |  | 2021-02-19 | 2021-02-19 | 1d | 0d |  | Analista de aplicaciones (E) [80%] | 6.4h |  | 240,000 | 240,000 |  | 0% | 0% |

| ID | WBS | Task | Type | Duration | Start | Finish | Predecessors | Baseline start | Baseline finish | Baseline duration | Total slack | Free slack | Resources | Work | Cost | Baseline cost | Planificado | % Planned |
| --- | --- | --- | --- | --- | --- | --- | --- | --- | --- | --- | --- | --- | --- | --- | --- | --- | --- | --- |
| 84 | 1.4.2 | **Pruebas de aceptación de usuario** |  | 24d | 2021-01-29 | 2021-03-03 |  | 2021-01-29 | 2021-03-03 | 24d | 0d |  |  | 108h | 4,363,082.4 | 4,363,082.4 | 0% | 0% |
| 85 | 1.4.2.1 | Requerir y alistar ambiente de pruebas |  | 1d | 2021-01-29 | 2021-01-29 | 73SS | 2021-01-29 | 2021-01-29 | 1d | 15d | 0d | Jefe de aplicaciones (E) [70%] | 5.6h | 262,500 | 262,500 | 0% | 0% |
| 86 | 1.4.2.2 | Instalar aplicación desarrollada |  | 1d | 2021-02-22 | 2021-02-22 | 85, 83 | 2021-02-22 | 2021-02-22 | 1d | 0d |  | Analista de aplicaciones (E) [80%] | 6.4h | 240,000 | 240,000 | 0% | 0% |
| 87 | 1.4.2.3 | Cargar datos y crear usuarios |  | 1d | 2021-02-23 | 2021-02-23 | 86SS | 2021-02-23 | 2021-02-23 | 1d | 0d |  | Analista de aplicaciones (E) [80%] | 6.4h | 240,000 | 240,000 | 0% | 0% |
| 88 | 1.4.2.4 | Realizar smoke tests al ambiente (validar ambiente) |  | 1d | 2021-02-24 | 2021-02-24 | 87 | 2021-02-24 | 2021-02-24 | 1d | 0d |  | Analista de aplicaciones (E) [80%] | 6.4h | 240,000 | 240,000 | 0% | 0% |
| 89 | 1.4.2.5 | Realizar plan de prueba |  | 1d | 2021-02-01 | 2021-02-01 | 85SS-1d | 2021-02-01 | 2021-02-01 | 1d | 14d | 0d | Gerente de proyecto (E) [80%] | 6.4h | 540,000 | 540,000 | 0% | 0% |
| 90 | 1.4.2.6 | Presentar plan de pruebas |  | 1d | 2021-02-02 | 2021-02-02 | 89 | 2021-02-02 | 2021-02-02 | 1d | 14d | 0d | Gerente de proyecto (E) [80%] | 6.4h | 540,000 | 540,000 | 0% | 0% |
| 91 | 1.4.2.7 | Identificar escenarios de prueba |  | 1d | 2021-02-03 | 2021-02-03 | 90 | 2021-02-03 | 2021-02-03 | 1d | 14d | 0d | Coordinador de proyectos [80%] | 6.4h | 283,430.4 | 283,430.4 | 0% | 0% |
| 92 | 1.4.2.8 | Realizar descripción de escenarios y resultados esperados |  | 1d | 2021-02-04 | 2021-02-04 | 91 | 2021-02-04 | 2021-02-04 | 1d | 14d |  | Ingeniero de proyectos 1 [50%] | 8h | 204,288 | 204,288 | 0% | 0% |
| 93 | 1.4.2.9 | Ejecutar pruebas y solucionar defectos |  | 3d | 2021-02-25 | 2021-03-01 | 92, 88 | 2021-02-25 | 2021-03-01 | 3d | 0d |  | Ingeniero de proyectos 1 [50%]; Analista de aplicaciones (E) [80%] | 43.2h | 1,332,864 | 1,332,864 | 0% | 0% |
| 94 | 1.4.2.10 | Realizar y entregar reporte de resultados |  | 1d | 2021-03-02 | 2021-03-02 | 93 | 2021-03-02 | 2021-03-02 | 1d | 0d |  | Analista de aplicaciones (E) [80%] | 6.4h | 240,000 | 240,000 | 0% | 0% |
| 95 | 1.4.2.11 | Actualizar versión de código testeado |  | 1d | 2021-03-03 | 2021-03-03 | 94 | 2021-03-03 | 2021-03-03 | 1d | 0d |  | Analista de aplicaciones (E) [80%] | 6.4h | 240,000 | 240,000 | 0% | 0% |
| 96 | 1.4.3 | **Pruebas de desempeño** |  | 31d | 2021-01-28 | 2021-03-11 |  | 2021-01-28 | 2021-03-11 | 31d | 0d |  |  | 77.6h | 3,409,644 | 3,409,644 | 0% | 0% |
| 97 | 1.4.3.1 | Requerir y alistar ambiente de pruebas |  | 1d | 2021-01-28 | 2021-01-28 | 73SS | 2021-01-28 | 2021-01-28 | 1d | 16d | 0d | Jefe de aplicaciones (E) [70%] | 5.6h | 262,500 | 262,500 | 0% | 0% |
| 98 | 1.4.3.2 | Instalar aplicación desarrollada |  | 1d | 2021-03-04 | 2021-03-04 | 97, 95 | 2021-03-04 | 2021-03-04 | 1d | 0d |  | Analista de aplicaciones (E) [80%] | 6.4h | 240,000 | 240,000 | 0% | 0% |
| 99 | 1.4.3.3 | Cargar datos y crear usuarios |  | 1d | 2021-03-05 | 2021-03-05 | 98SS | 2021-03-05 | 2021-03-05 | 1d | 0d |  | Analista de aplicaciones (E) [80%] | 6.4h | 240,000 | 240,000 | 0% | 0% |
| 100 | 1.4.3.4 | Realizar smoke tests al ambiente (validar ambiente) |  | 1d | 2021-03-08 | 2021-03-08 | 99 | 2021-03-08 | 2021-03-08 | 1d | 0d |  | Analista de aplicaciones (E) [80%] | 6.4h | 240,000 | 240,000 | 0% | 0% |
| 101 | 1.4.3.5 | Realizar plan de prueba |  | 1d | 2021-02-01 | 2021-02-01 | 97SS-1d | 2021-02-01 | 2021-02-01 | 1d | 14d | 0d | Jefe de aplicaciones (E) [70%] | 5.6h | 262,500 | 262,500 | 0% | 0% |
| 102 | 1.4.3.6 | Presentar plan de pruebas |  | 1d | 2021-02-04 | 2021-02-04 | 101 | 2021-02-04 | 2021-02-04 | 1d | 13d | 0d | Jefe de aplicaciones (E) [70%] | 5.6h | 262,500 | 262,500 | 0% | 0% |
| 103 | 1.4.3.7 | Identificar escenarios de prueba |  | 1d | 2021-02-05 | 2021-02-05 | 102 | 2021-02-05 | 2021-02-05 | 1d | 13d | 0d | Jefe de aplicaciones (E) [70%] | 5.6h | 262,500 | 262,500 | 0% | 0% |
| 104 | 1.4.3.8 | Realizar descripción de escenarios y resultados esperados |  | 2d | 2021-02-08 | 2021-02-17 | 103 | 2021-02-08 | 2021-02-17 | 2d | 13d |  | Analista de aplicaciones (E) [80%]; Coordinador de calidad [50%] | 10.4h | 379,644 | 379,644 | 0% | 0% |
| 105 | 1.4.3.9 | Ejecutar pruebas y solucionar defectos |  | 2d | 2021-03-09 | 2021-03-10 | 104, 100 | 2021-03-09 | 2021-03-10 | 2d | 0d |  | Analista de aplicaciones (E) [80%] | 12.8h | 480,000 | 480,000 | 0% | 0% |
| 106 | 1.4.3.10 | Realizar y entregar reporte de resultados |  | 1d | 2021-03-11 | 2021-03-11 | 105 | 2021-03-11 | 2021-03-11 | 1d | 0d |  | Analista de aplicaciones (E) [80%]; Gerente de proyecto (E) [80%] | 12.8h | 780,000 | 780,000 | 0% | 0% |
| 107 | 1.5 | Pruebas completadas | milestone | 0d | 2021-03-11 | 2021-03-11 | 96 | 2021-03-11 | 2021-03-11 | 0d | 44d |  |  |  |  |  | 0% | 0% |

| ID | WBS | Task | Type | Duration | Start | Finish | Predecessors | Baseline start | Baseline finish | Baseline duration | Total slack | Free slack | Resources | Work | Cost | Baseline cost | Planificado | % Planned |
| --- | --- | --- | --- | --- | --- | --- | --- | --- | --- | --- | --- | --- | --- | --- | --- | --- | --- | --- |
| 108 | 1.6 | **Almacenamiento en la nube** |  | 33d | 2021-02-02 | 2021-03-18 |  | 2021-02-02 | 2021-03-18 | 33d | 26d |  |  | 65.6h | 3,075,000 | 3,075,000 | 0% | 0% |
| 109 | 1.6.1 | Levantar requerimientos de infraestructura |  | 1d | 2021-02-02 | 2021-02-02 | 73SS | 2021-02-02 | 2021-02-02 | 1d | 26d | 0d | Jefe de aplicaciones (E) [70%] | 5.6h | 262,500 | 262,500 | 0% | 0% |
| 110 | 1.6.2 | Requerir y alistar ambiente |  | 1d | 2021-02-03 | 2021-02-03 | 109 | 2021-02-03 | 2021-02-03 | 1d | 26d |  | Jefe de aplicaciones (E) [70%] | 5.6h | 262,500 | 262,500 | 0% | 0% |
| 111 | 1.6.3 | Realizar configuraciones de integraciones |  | 2d | 2021-03-12 | 2021-03-15 | 110, 106 | 2021-03-12 | 2021-03-15 | 2d | 0d |  | Jefe de aplicaciones (E) [70%] | 11.2h | 525,000 | 525,000 | 0% | 0% |
| 112 | 1.6.4 | Actualizar documentación técnica |  | 1d | 2021-03-16 | 2021-03-16 | 111 | 2021-03-16 | 2021-03-16 | 1d | 23d | 0d | Jefe de aplicaciones (E) [70%] | 5.6h | 262,500 | 262,500 | 0% | 0% |
| 113 | 1.6.5 | Planificar pruebas funcionales |  | 2d | 2021-02-08 | 2021-02-18 | 109SS | 2021-02-08 | 2021-02-18 | 2d | 59d |  | Jefe de aplicaciones (E) [70%]; Analista de aplicaciones (E) [80%] | 12h | 502,500 | 502,500 | 0% | 0% |
| 114 | 1.6.6 | Ejecutar pruebas y solucionar defectos |  | 2d | 2021-03-16 | 2021-03-17 | 93, 111 | 2021-03-16 | 2021-03-17 | 2d | 0d |  | Analista de aplicaciones (E) [80%] | 12.8h | 480,000 | 480,000 | 0% | 0% |
| 115 | 1.6.7 | Entregar reporte de pruebas |  | 1d | 2021-03-18 | 2021-03-18 | 114 | 2021-03-18 | 2021-03-18 | 1d | 0d |  | Analista de aplicaciones (E) [80%]; Gerente de proyecto (E) [80%] | 12.8h | 780,000 | 780,000 | 0% | 0% |
| 116 | 1.7 | **Entrenamientos** |  | 47d | 2021-02-01 | 2021-04-09 |  | 2021-02-01 | 2021-04-09 | 47d | 26d |  |  | 133.6h | 8,707,370.4 | 8,707,370.4 | 0% | 0% |
| 117 | 1.7.1 | Definir estrategia de entrenamiento |  | 4d | 2021-02-01 | 2021-02-04 | 85 | 2021-02-01 | 2021-02-04 | 4d | 45d | 0d | Gerente de proyecto (E) [80%]; Líder de RH [50%] | 20.8h | 1,359,288 | 1,359,288 | 0% | 0% |
| 118 | 1.7.2 | Presentar estrategia de entrenamientos |  | 1d | 2021-02-05 | 2021-02-05 | 117 | 2021-02-05 | 2021-02-05 | 1d | 45d | 0d | Gerente de proyecto (E) [80%]; Coordinador de proyectos [80%] | 12.8h | 823,430.4 | 823,430.4 | 0% | 0% |
| 119 | 1.7.3 | Crear plan de entrenamientos |  | 1d | 2021-02-08 | 2021-02-08 | 118 | 2021-02-08 | 2021-02-08 | 1d | 45d | 0d | Gerente de proyecto (E) [80%] | 6.4h | 540,000 | 540,000 | 0% | 0% |
| 120 | 1.7.4 | Crear material de entrenamiento |  | 2d | 2021-02-09 | 2021-02-10 | 119 | 2021-02-09 | 2021-02-10 | 2d | 45d | 21d | Jefe de aplicaciones (E) [70%] | 11.2h | 525,000 | 525,000 | 0% | 0% |
| 121 | 1.7.5 | Ejecutar entrenamientos |  | 6d | 2021-03-12 | 2021-03-19 | 120, 106 | 2021-03-12 | 2021-03-19 | 6d | 24d | 0d | Gerente de proyecto (E) [80%]; Coordinador de proyectos [80%] | 64h | 4,117,152 | 4,117,152 | 0% | 0% |
| 122 | 1.7.6 | Realizar evaluaciones |  | 1d | 2021-04-07 | 2021-04-07 | 121 | 2021-04-07 | 2021-04-07 | 1d | 26d | 0d | Jefe de aplicaciones (E) [70%] | 5.6h | 262,500 | 262,500 | 0% | 0% |
| 123 | 1.7.7 | Generar el reporte de entrenamientos |  | 1d | 2021-04-08 | 2021-04-08 | 122 | 2021-04-08 | 2021-04-08 | 1d | 26d | 0d | Gerente de proyecto (E) [80%] | 6.4h | 540,000 | 540,000 | 0% | 0% |
| 124 | 1.7.8 | Presentar reporte de entrenamientos a interesados clave |  | 1d | 2021-04-09 | 2021-04-09 | 123 | 2021-04-09 | 2021-04-09 | 1d | 26d | 0d | Gerente de proyecto (E) [80%] | 6.4h | 540,000 | 540,000 | 0% | 0% |
| 125 | 1.7.9 | Entrenamientos terminados | milestone | 0d | 2021-04-09 | 2021-04-09 | 124 | 2021-04-09 | 2021-04-09 | 0d | 26d |  |  |  |  |  | 0% | 0% |
| 126 | 1.8 | **Procedimientos** |  | 13d | 2021-03-18 | 2021-04-08 |  | 2021-03-18 | 2021-04-08 | 13d | 27d |  |  | 89.6h | 2,993,025.6 | 2,993,025.6 | 0% | 0% |
| 127 | 1.8.1 | Revisar y actualizar procedimientos existentes |  | 2d | 2021-03-18 | 2021-03-19 | 121FS-2d | 2021-03-18 | 2021-03-19 | 2d | 28d | 0d | Ingeniero de proyectos 1 [50%] | 16h | 408,576 | 408,576 | 0% | 0% |
| 128 | 1.8.2 | Validar y aprobar procedimientos existentes |  | 4d | 2021-03-23 | 2021-03-26 | 127 | 2021-03-23 | 2021-03-26 | 4d | 28d | 0d | Coordinador de proyectos [80%]; Coordinador de calidad [50%] | 20.8h | 846,148.8 | 846,148.8 | 0% | 0% |
| 129 | 1.8.3 | Crear nuevos procedimientos |  | 3d | 2021-03-29 | 2021-03-31 | 128 | 2021-03-29 | 2021-03-31 | 3d | 28d | 0d | Ingeniero de proyectos 1 [50%] | 24h | 612,864 | 612,864 | 0% | 0% |
| 130 | 1.8.4 | Validar y aprobar nuevos procedimientos |  | 2d | 2021-04-05 | 2021-04-06 | 129 | 2021-04-05 | 2021-04-06 | 2d | 28d | 0d | Coordinador de proyectos [80%]; Coordinador de calidad [50%] | 20.8h | 846,148.8 | 846,148.8 | 0% | 0% |
| 131 | 1.8.5 | Realizar revisión final |  | 1d | 2021-04-07 | 2021-04-07 | 130 | 2021-04-07 | 2021-04-07 | 1d | 28d |  | Coordinador de calidad [50%] | 4h | 139,644 | 139,644 | 0% | 0% |
| 132 | 1.8.6 | Publicar procedimientos |  | 1d | 2021-04-08 | 2021-04-08 | 130, 128 | 2021-04-08 | 2021-04-08 | 1d | 27d | 0d | Coordinador de calidad [50%] | 4h | 139,644 | 139,644 | 0% | 0% |
| 133 | 1.8.7 | Procedimientos publicados | milestone | 0d | 2021-04-08 | 2021-04-08 | 132 | 2021-04-08 | 2021-04-08 | 0d | 27d |  |  |  |  |  | 0% | 0% |

| ID | WBS | Task | Type | Duration | Start | Finish | Predecessors | Baseline start | Baseline finish | Baseline duration | Total slack | Free slack | Resources | Work | Cost | Baseline cost | Planificado | % Planned |
| --- | --- | --- | --- | --- | --- | --- | --- | --- | --- | --- | --- | --- | --- | --- | --- | --- | --- | --- |
| 134 | 1.9 | **Implementación** |  | 35d | 2021-02-23 | 2021-04-15 |  | 2021-02-23 | 2021-04-16 | 36d | 18d |  |  | 213.6h | 54,550,677.4 | 54,813,177.4 | 0% | 0% |
| 135 | 1.9.1 | Actualizar plan de infraestructura de TI |  | 2d | 2021-03-17 | 2021-03-18 | 112 | 2021-03-17 | 2021-03-18 | 2d | 23d | 0d | Jefe de aplicaciones (E) [70%] | 11.2h | 525,000 | 525,000 | 0% | 0% |
| 136 | 1.9.2 | Realizar levantamiento de información de infraestructura requerida para PRD |  | 4d | 2021-02-25 | 2021-03-02 | 88 | 2021-02-25 | 2021-03-02 | 4d | 34d | 0d | Jefe de aplicaciones (E) [70%]; Coordinador de TI [50%] | 28.8h | 1,318,932 | 1,318,932 | 0% | 0% |
| 137 | 1.9.3 | Solicitar infraestructura de TI |  | 1d | 2021-03-03 | 2021-03-03 | 136 | 2021-03-03 | 2021-03-03 | 1d | 34d | 11d | Jefe de aplicaciones (E) [70%] | 5.6h | 262,500 | 262,500 | 0% | 0% |
| 138 | 1.9.4 | Recibir infraestructura de TI para producción |  | 2d | 2021-04-08 | 2021-04-09 | 135, 137 | 2021-04-08 | 2021-04-09 | 2d | 26d |  | Jefe de aplicaciones (E) [70%] | 11.2h | 525,000 | 525,000 | 0% | 0% |
| 139 | 1.9.5 | Alistar aplicación desarrollada en su ultima versión. |  | 1d | 2021-03-19 | 2021-03-19 | 115, 106 | 2021-03-19 | 2021-03-19 | 1d | 0d |  | Analista de aplicaciones (E) [80%] | 6.4h | 240,000 | 240,000 | 0% | 0% |
| 140 | 1.9.6 | Alistar carga de datos |  | 1d | 2021-03-19 | 2021-03-19 | 139SS | 2021-03-19 | 2021-03-19 | 1d | 0d |  | Jefe de aplicaciones (E) [70%] | 5.6h | 262,500 | 262,500 | 0% | 0% |
| 141 | 1.9.7 | Definir y segregar usuarios |  | 3d | 2021-02-23 | 2021-02-25 | 87SS | 2021-02-23 | 2021-02-25 | 3d | 22d |  | Jefe de aplicaciones (E) [70%]; Coordinador de proyectos [80%] | 36h | 1,637,791.2 | 1,637,791.2 | 0% | 0% |
| 142 | 1.9.8 | Realizar plan de ensayos |  | 2d | 2021-03-23 | 2021-03-24 | 140, 25 | 2021-03-23 | 2021-03-24 | 2d | 0d |  | Jefe de aplicaciones (E) [70%]; Coordinador de proyectos [80%] | 24h | 1,091,860.8 | 1,091,860.8 | 0% | 0% |
| 143 | 1.9.9 | Ejecutar ensayos |  | 1d | 2021-03-30 | 2021-03-30 | 142 | 2021-03-30 | 2021-03-30 | 1d | 0d |  | Jefe de aplicaciones (E) [70%] | 5.6h | 262,500 | 262,500 | 0% | 0% |
| 144 | 1.9.10 | Entregar reporte de ensayos |  | 1d | 2021-04-12 | 2021-04-12 | 143 | 2021-04-12 | 2021-04-12 | 1d | 25d |  | Jefe de aplicaciones (E) [70%] | 5.6h | 262,500 | 262,500 | 0% | 0% |
| 145 | 1.9.11 | Actualizar plan de cutover |  | 3d | 2021-03-25 | 2021-03-29 | 25, 142 | 2021-03-25 | 2021-03-29 | 3d | 1d | 0d | Jefe de aplicaciones (E) [70%] | 16.8h | 787,500 | 787,500 | 0% | 0% |
| 146 | 1.9.12 | Realizar instalación de ultima versión del desarrollo |  | 1d | 2021-03-31 | 2021-03-31 | 145, 143, 139 | 2021-03-31 | 2021-03-31 | 1d | 0d |  | Jefe de aplicaciones (E) [70%] | 5.6h | 262,500 | 262,500 | 0% | 0% |
| 147 | 1.9.13 | Cargar datos - Go Live |  | 1d | 2021-03-31 | 2021-03-31 | 146SS, 140 | 2021-03-31 | 2021-03-31 | 1d | 0d |  | Analista de aplicaciones (E) [80%] | 6.4h | 240,000 | 240,000 | 0% | 0% |
| 148 | 1.9.14 | Habilitar/Configurar usuarios |  | 2d | 2021-03-31 | 2021-04-05 | 147SS, 141 | 2021-03-31 | 2021-04-05 | 2d | 0d |  | Coordinador de TI [50%]; Jefe de aplicaciones (E) [70%] | 9.6h | 439,644 | 439,644 | 0% | 0% |
| 149 | 1.9.15 | Salir a producción |  | 3d | 2021-03-31 | 2021-04-06 | 148SS | 2021-03-31 | 2021-04-06 | 3d | 0d |  | Jefe de aplicaciones (E) [70%]; Coordinador de TI [50%]; Gerente de proyecto (E) [80%]; Coordinador de proyectos [80%] | 22.4h | 1,263,074.4 | 1,263,074.4 | 0% | 0% |
| 150 | 1.9.16 | Actualizar documentos técnicos |  | 2d | 2021-04-14 | 2021-04-15 | 149 | 2021-04-14 | 2021-04-15 | 2d | 22d | 0d | Analista de aplicaciones (E) [80%] | 12.8h | 480,000 | 480,000 | 0% | 0% |
| 151 | 1.9.17 | Entregar documentos técnicos actualizados | milestone | 0d | 2021-04-15 | 2021-04-15 | 150 | 2021-04-16 | 2021-04-16 | 1d | 22d |  | Jefe de aplicaciones (E) [70%] |  |  | 262,500 | 0% | 0% |
| 152 | 1.9.18 | Go Live ejecutado | milestone | 0d | 2021-03-31 | 2021-03-31 | 149SS | 2021-03-31 | 2021-03-31 | 0d | 32d |  |  |  |  |  | 0% | 0% |
| 153 | 1.9.19 | Licenciar aplicativo parte 2 | milestone | 0d | 2021-03-25 | 2021-03-25 | 145SS | 2021-03-25 | 2021-03-25 | 0d | 36d | 0d |  |  | 38,689,375 | 38,689,375 | 0% | 0% |
| 154 | 1.9.20 | Activar servicio en la nube | milestone | 0d | 2021-03-25 | 2021-03-25 | 153SS | 2021-03-25 | 2021-03-25 | 0d | 36d |  |  |  | 6,000,000 | 6,000,000 | 0% | 0% |
| 155 | 1.10 | **Estabilización y soporte** |  | 18d | 2021-03-25 | 2021-04-21 |  | 2021-03-25 | 2021-04-21 | 18d | 7d |  |  | 88h | 4,991,860.8 | 4,991,860.8 | 0% | 0% |
| 156 | 1.10.1 | Programar monitoreo diario |  | 1d | 2021-03-25 | 2021-03-25 | 145SS | 2021-03-25 | 2021-03-25 | 1d | 35d |  | Gerente de proyecto (E) [80%] | 6.4h | 540,000 | 540,000 | 0% | 0% |
| 157 | 1.10.2 | Resolver errores presentados en producción |  | 5d | 2021-04-07 | 2021-04-13 | 149 | 2021-04-07 | 2021-04-13 | 5d | 0d |  | Analista de aplicaciones (E) [80%] | 32h | 1,200,000 | 1,200,000 | 0% | 0% |
| 158 | 1.10.3 | Crear y entregar reporte de estabilización |  | 2d | 2021-04-14 | 2021-04-15 | 157 | 2021-04-14 | 2021-04-15 | 2d | 0d |  | Jefe de aplicaciones (E) [70%] | 11.2h | 525,000 | 525,000 | 0% | 0% |
| 159 | 1.10.4 | Gestionar entrega y validación de actas de cierre |  | 2d | 2021-04-14 | 2021-04-15 | 158FF | 2021-04-14 | 2021-04-15 | 2d | 0d |  | Gerente de proyecto (E) [80%] | 12.8h | 1,080,000 | 1,080,000 | 0% | 0% |
| 160 | 1.10.5 | Completar cierre de pendientes |  | 2d | 2021-04-16 | 2021-04-19 | 159 | 2021-04-16 | 2021-04-19 | 2d | 0d |  | Gerente de proyecto (E) [80%] | 12.8h | 1,080,000 | 1,080,000 | 0% | 0% |
| 161 | 1.10.6 | Aprobar entregables |  | 2d | 2021-04-20 | 2021-04-21 | 160 | 2021-04-20 | 2021-04-21 | 2d | 0d |  | Coordinador de proyectos [80%] | 12.8h | 566,860.8 | 566,860.8 | 0% | 0% |
| 162 | 1.11 | Proyecto cerrado | milestone | 0d | 2021-05-17 | 2021-05-17 | 36 | 2021-05-17 | 2021-05-17 | 0d | 0d |  |  |  |  |  | 0% | 0% |
| 163 | 1.12 | Reserva de contingencia |  | 1d | 2021-05-05 | 2021-05-05 | 36SS | 2021-05-05 | 2021-05-05 | 1d | 8d |  |  |  | 18,953,019.2 | 18,953,019.2 | 0% | 0% |
